# PFS timing strobe

Schedule from MS Project, 2012-11-19 to 2012-11-20, 24 hours a day.

## Calendars

- 24 Hours: Mon-Sun 00:00-24:00.

## Resources

| Resource |
| --- |
| OBCP |
| PFICS |
| MCS |
| MPS |

## Schedule

| ID | Task | Duration | Start | Finish | Predecessors | Total slack | Free slack | Constraint | Resources | Work |
| --- | --- | --- | --- | --- | --- | --- | --- | --- | --- | --- |
| 1 | MCS exposure | 0.01d | 2012-11-19 00:00 | 2012-11-19 00:14 |  | 0d |  | start no earlier than 2012-11-19 00:00 | OBCP | 0.24h |
| 2 | MCS readout | 0.5d | 2012-11-19 00:14 | 2012-11-19 12:14 | 1 | 0d |  |  |  |  |
| 3 | MCS calibration and centroid | 0.75d | 2012-11-19 02:38 | 2012-11-19 20:38 | 2SS+0.1d | 0.66d | 0d |  |  |  |
| 4 | data transfer to PFICS | 0.01d | 2012-11-19 20:38 | 2012-11-19 20:52 | 3 | 0.66d |  |  |  |  |
| 5 | MCS exposure | 0.01d | 2012-11-19 12:14 | 2012-11-19 12:28 | 2 | 0d |  |  |  |  |
| 6 | MCS readout | 0.5d | 2012-11-19 12:28 | 2012-11-20 00:28 | 5 | 0d |  |  |  |  |
| 7 | MCS calibration and centroid | 0.75d | 2012-11-19 14:52 | 2012-11-20 08:52 | 6SS+0.1d | 0.51d | 0d |  |  |  |
| 8 | data transfer to PFICS | 0.01d | 2012-11-20 08:52 | 2012-11-20 09:07 | 7 | 0.51d |  |  |  |  |
| 9 | MCS exposure | 0.01d | 2012-11-20 00:28 | 2012-11-20 00:43 | 6 | 0d |  |  |  |  |
| 10 | MCS readout | 0.5d | 2012-11-20 00:43 | 2012-11-20 12:43 | 9 | 0d |  |  |  |  |
| 11 | MCS calibration and centroid | 0.75d | 2012-11-20 03:07 | 2012-11-20 21:07 | 10SS+0.1d | 0d |  |  |  |  |
| 12 | data transfer to PFICS | 0.01d | 2012-11-20 21:07 | 2012-11-20 21:21 | 11 | 0d |  |  |  |  |
