# PFS timing syseng127

Schedule from MS Project, 2012-11-19 to 2013-02-06, 24 hours a day.

## Calendars

- 24 Hours: Mon-Sun 00:00-24:00.

## Resources

| Resource |
| --- |
| RMS |
| OBCP |
| Spectrometer |
| PFICS |

## Schedule

| ID | Task | Type | Duration | Start | Finish | Predecessors | Total slack | Constraint | Resources | Work |
| --- | --- | --- | --- | --- | --- | --- | --- | --- | --- | --- |
| 1 | close shutter |  | 2d | 2012-11-19 | 2012-11-21 |  | 0d | start no earlier than 2012-11-19 | OBCP | 48h |
| 2 | read out CCDs |  | 33d | 2012-11-21 | 2012-12-24 | 1 | 44.5d |  | Spectrometer | 792h |
| 3 | slew telescope and rotator |  | 7d | 2012-11-21 | 2012-11-28 | 1 | 0d |  | OBCP | 168h |
| 4 | settle telescope and rotator |  | 5d | 2012-11-28 | 2012-12-03 | 3 | 0d |  | OBCP | 120h |
| 5 | stop rotator | milestone | 0d | 2012-12-03 | 2012-12-03 | 4 | 65.5d |  | OBCP |  |
| 6 | back illuminators on | milestone | 0d | 2012-12-03 | 2012-12-03 | 4 | 65.5d |  | PFICS |  |
| 7 | fiber configuration |  | 43.5d | 2012-12-03 | 2013-01-15 | 4 | 0d |  | PFICS | 1044h |
| 8 | back illuminators off | milestone | 0d | 2013-01-15 | 2013-01-15 | 7 | 22d |  | PFICS |  |
| 9 | start rotator | milestone | 0d | 2013-01-15 | 2013-01-15 | 7 | 22d |  | OBCP |  |
| 10 | rotate to target |  | 7d | 2013-01-15 | 2013-01-22 | 7 | 0d |  | OBCP | 168h |
| 11 | field acquisition |  | 7d | 2013-01-22 | 2013-01-29 | 10 | 0d |  | OBCP | 168h |
| 12 | autoguide and settle |  | 6d | 2013-01-29 | 2013-02-04 | 11 | 0d |  | OBCP | 144h |
| 13 | open shutter |  | 2d | 2013-02-04 | 2013-02-06 | 12 | 0d |  | OBCP | 48h |
